# 110-10 kV Nemenčinės TP 110 kV skirstyklos rekonstravimas

Schedule from MS Project, 2025-10-30 to 2026-11-19, status date 2025-07-16, costs in €, A marks actual dates.

## Calendars

- Standard: Mon-Fri 08:00-12:00, 13:00-17:00; Sat-Sun off. Exceptions (off unless hours are given): 2013-01-01 to 2030-01-01 (Naujieji metai, recurring), 2013-02-16 to 2030-02-16 (Valstybės atkurimo diena, recurring), 2013-03-11 to 2030-03-11 (Nepriklausomybes atkurimo diena, recurring), 2013-05-01 to 2030-05-01 (Tarptautine darbininku diena, recurring), 2013-06-24 to 2030-06-24 (Jonines (Rasos), recurring), 2013-07-06 to 2030-07-06 (Valstybes (Lietuvos karaliaus Mindaugo karunavimo) diena, recurring), 2013-08-15 to 2030-08-15 (Zoline, Sv. Mergeles Marijos dangun emimo svente, recurring), 2013-11-01 to 2030-11-01 (Visu sventuju diena, recurring), 2013-12-24 to 2030-12-24 (Sv. Kucios, recurring), 2013-12-25 to 2030-12-25 (Sv. Kaledos, recurring), 2013-12-26 to 2030-12-26 (Sv. Kaledos (antroji diena), recurring), 2019-06-21 to 2030-12-27 07:30-11:30, 12:15-15:15 (Darbo diena (V) 07:30-15:15, recurring), 2024-04-03 to 2029-01-15 07:30-11:30, 12:15-16:30 (Darbo diena (I-IV) 07:30-16:30, recurring), 2025-12-24 (Kūčios), 2025-12-25 (Kalėdos), 2025-12-26 (Kalėdos 2d), 2026-01-01 (Naujieji metai), 2026-02-16 (Vasario 16), 2026-03-11 (kovo 11), 2026-04-06 (Sv. Velykos (antroji diena)), 2026-05-01 (Darbo šventė), 2026-06-24 (Joninės), 2026-07-06 (Liepos 6d), 2026-11-02 (Vėlinės).

## Resources

| Resource | Group | Rate |
| --- | --- | --- |
| _3-ųjų šalių grupė |  | 17.8 |
| Aleksandr Olefir | PTD Infrastruktūros priežiūros centras (IPC) | 17.8 |
| Algirdas Platakis | ITTAD ITTC Valdymo sistemų grupė | 17.8 |
| Alvidas Šinkūnas | PTD IPC Rytų regionas | 17.8 |
| Antanas Rožanskas | PTD IPC Pietų regionas | 17.8 |
| Arūnas Kaušas | PTD IPC Šiaurės regionas | 17.8 |
| Arūnas Kontrimavičius | PTD IPC Šiaurės regionas | 17.8 |
| Arūnas Pazniokas | PTD IPC Rytų regionas | 17.8 |
| Audrius Baranauskas | SD Inovacijų skyrius | 17.8 |
| Aurimas Kniuras | PTD IPC Šiaurės regionas | 17.8 |
| Dainius Jasiulionis | ITTAD ITTC Telekomunikacijų infrastruktūros grupė | 17.8 |
| Darius Jankauskas | PTD IPC Pietų regionas | 17.8 |
| Darius Vėta | PTD IPC Rytų regionas | 17.8 |
| Darius Žvirblis | VAD Informacijos saugos skyrius | 17.8 |
| Donatas Kilas | SVD SPS Sistemos techninių reikalavimų grupė | 17.8 |
| Edvardas Duoba | PTD IPC Vakarų regionas | 17.8 |
| Egidijus Bargaila | SVD SPS Atjungimų koordinavimo grupė | 17.8 |
| Egidijus Kutka | PTD IPC Rytų regionas | 17.8 |
| Egidijus Stanionis | PTD IPC Pietų regionas | 17.8 |
| Evaldas Auga | PTD IPC Vakarų regionas | 17.8 |
| Evaldas Pocius | PTD IPC Vakarų regionas | 17.8 |
| Gediminas Černiauskas | ITTAD ITTC Valdymo sistemų grupė | 17.8 |
| Gediminas Žukauskas | PTD IPC Pietų regionas | 17.8 |
| Gintaras Stasionis | PTD IPC Pietų regionas | 17.8 |
| Gintaris Leonas Janavičius | ITTAD ITTC Telekomunikacijų infrastruktūros grupė | 17.8 |
| Gražvydas Ananis | PTD Darbuotojų saugos ir aplinkosaugos skyrius | 17.8 |
| Irmantas Strumyla | PTD Infrastruktūros priežiūros centras (IPC) | 17.8 |
| Jonas Murauskas | SVD ROPS Rinkos ir perdavimo paslaugų apskaitos grupė | 17.8 |
| Jonas Šarnauskas | PTD IPC Šiaurės regionas | 17.8 |
| Josif Piraškevič | PTD IPC Diagnostikos grupė | 17.8 |
| Jovita Kildienė | AEIC Klientų aptarnavimo grupė | 17.8 |
| Juozas Domašauskas | PTD IPC Pietų regionas | 17.8 |
| Karolis Čepaitis | PTD IPC Rytų regionas | 17.8 |
| Kazimieras Ivanauskas | ITTAD ITTC Telekomunikacijų infrastruktūros grupė | 17.8 |
| Kęstutis Rokas | ITTAD ITTC Duomenų perdavimo grupė | 17.8 |
| Klemensas Stančiauskas | PTD IPC Pietų regionas | 17.8 |
| Linardas Mockus | PTD IPC Vakarų regionas | 17.8 |
| Mantas Krapavickas | VAD Fizinės saugos skyrius | 17.8 |
| Marius Karmonas | PTD IPC Rytų regionas | 17.8 |
| Marius Statkus | SVD SPS Atjungimų koordinavimo grupė | 17.8 |
| Marius Vidugiris | PTD Infrastruktūros priežiūros centras (IPC) | 17.8 |
| Mindaugas Kieras | PTD IPC Pietų regionas | 17.8 |
| Mindaugas Mikulis | ITTAD ITTC Valdymo sistemų grupė | 17.8 |
| Mindaugas Šimkus | ITTAD ITTC Duomenų perdavimo grupė | 17.8 |
| Mindaugas Štaras | ITTAD ITTC Duomenų perdavimo grupė | 17.8 |
| Olga Darulienė | AEIC Klientų aptarnavimo grupė | 17.8 |
| Paulius Cicėnas | SPĮC Rytinės Lietuvos grupė | 17.8 |
| Paulius Raila | PTD TechS RAA įrenginių grupė | 17.8 |
| Pavelas Kuznecovas | PTD Technikos skyrius | 17.8 |
| Raimondas Keblas | ITTAD ITTC Telekomunikacijų infrastruktūros grupė | 17.8 |
| Raimondas Pūras | VAD Informacijos saugos skyrius | 17.8 |
| Raimundas Ambrozaitis | PTD IPC Vakarų regionas | 17.8 |
| Raimundas Garbauskas | PTD IPC Pietų regionas | 17.8 |
| Raimundas Vilemas | PTD IPC Šiaurės regionas | 17.8 |
| Ramūnas Bikulčius | SD Strategijos ir tyrimų skyrius | 17.8 |
| Ramūnas Pocevičius | PTD IPC Rytų regionas | 17.8 |
| Ramūnas Ponelis | PTD Technikos skyrius | 17.8 |
| Regina Platakienė | ITTAD ITTC Valdymo sistemų grupė | 17.8 |
| Remigijus Narmontas | PTD IPC Vakarų regionas | 17.8 |
| Remigijus Petkus | PTD IPC Vakarų regionas | 17.8 |
| Rimantas Dulskis | ITTAD ITTC Telekomunikacijų infrastruktūros grupė | 17.8 |
| Rimantas Mackevičius | PTD IPC Rytų regionas | 17.8 |
| Rimantas Mačiulskis | ITTAD ITTC Telekomunikacijų infrastruktūros grupė | 17.8 |
| Rimantas Redecki | SVD Sistemos patikimumo skyrius | 17.8 |
| Rimantas Rutkauskas | SD Strategijos ir tyrimų skyrius | 17.8 |
| Rimantas Vaitkus | PTD IPC Vakarų regionas | 17.8 |
| Rimas Savukas | PTD IPC Rytų regionas | 17.8 |
| Rytis Šauklys | SVD SPS Atjungimų koordinavimo grupė | 17.8 |
| Rokas Muleravičius | PTD Sisteminių įrenginių priežiūros skyrius | 17.8 |
| Rolandas Medžiaušis | PTD IPC Šiaurės regionas | 17.8 |
| Romanas Mikalauskas | PTD TechS Pastočių pirminių įrenginių grupė | 17.8 |
| Romas Pangonis | SVD SPS Sistemos techninių reikalavimų grupė | 17.8 |
| Salvijus Šimkevičius | PTD IPC Šiaurės regionas | 17.8 |
| Saulius Ramanauskas | PTD IPC Šiaurės regionas | 17.8 |
| Sigitas Černas | PTD IPC Šiaurės regionas | 17.8 |
| Tomas Kirdonis | ITTAD ITTC Telekomunikacijų infrastruktūros grupė | 17.8 |
| Vaclovas Lygnugaris | PTD IPC Rytų regionas | 17.8 |
| Vaidas Žebelis | PTD Technikos skyrius | 17.8 |
| Vaidotas Stankevičius | SPĮC Rytinės Lietuvos grupė | 17.8 |
| Valdas Rėkus | PTD IPC Rytų regionas | 17.8 |
| Valdas Slapšys | PTD IPC Šiaurės regionas | 17.8 |
| Valerijus Makarovas | SID Nekilnojamojo turto ir planavimo skyrius | 17.8 |
| Vidas Noreika | SVD SVC Operatyvinio valdymo grupė | 17.8 |
| Vidmantas Baliukonis | PTD Darbuotojų saugos ir aplinkosaugos skyrius | 17.8 |
| Vidmantas Barkus | PTD IPC Vakarų regionas | 17.8 |
| Vilius Pakulis | PTD TechS Pastočių pirminių įrenginių grupė | 17.8 |
| Vingaudas Milišauskas | ITTAD ITTC Duomenų perdavimo grupė | 17.8 |
| Vytautas Kunigauskas | ITTAD ITTC Duomenų perdavimo grupė | 17.8 |
| Vytautas Šatinskis | PTD TechS Pastočių pirminių įrenginių grupė | 17.8 |
| Žilvinas Zencevičius | SVD SVC Technologinio valdymo grupė | 17.8 |
| Živilė Razulevičiūtė | AEIC Klientų aptarnavimo grupė | 17.8 |
| Darius Sirgedas | PTD IPC Rytų regionas | 17.8 |
| Skirmantė Dubovikienė | SID Nekilnojamojo turto ir planavimo skyrius | 17.8 |
| Vytenis Povilas Čironis | PTD TechS Pastočių pirminių įrenginių grupė | 17.8 |
| Kęstutis Liepuonius | PTD Infrastruktūros priežiūros centras (IPC) | 17.8 |
| Raimondas Tumas | ITTAD ITTC Duomenų perdavimo grupė | 17.8 |
| Giedrius Gailevičius | SPĮC Rytinės Lietuvos grupė | 17.8 |
| Nikolaj Komisarenko | PTD IPC Diagnostikos grupė | 17.8 |
| _ITTAD ITTC DPG grupės vadovas |  | 17.8 |
| _ITTAD ITTC TIG grupės vadovas |  | 17.8 |
| _VAD FSS apsaugos sistemų specialistas |  | 17.8 |
| _PTD DSAS darbuotojų saugos ir sveikatos vyresnysis inžinierius |  | 17.8 |
| _SVD ROPS RPPAG elektros apskaitų vadovaujantis inžinierius |  | 17.8 |
| _ITTAD ITTC DPG PVS administratorius |  | 17.8 |
| _ITTAD ITTC TIG technologinio tinklo vyresnysis inžinierius |  | 17.8 |
| _PTD IPC Statybų priežiūros proceso vadovas |  | 17.8 |
| _PTD TCHS EPLG grupės vadovas |  | 17.8 |
| _PTD TCHS PPĮG pastočių vyresnysis inžinierius |  | 17.8 |
| _PTD TCHS RAA įrenginių grupės RAA vyresnysis inžinierius |  | 17.8 |
| _SVD SVC OVG ekspertas |  | 17.8 |
| _SVD SVC TVG technologinio valdymo vyresnysis inžinierius |  | 17.8 |
| _ITTAD ITTC DPG duomenų tinklo administratorius (IP) |  | 17.8 |
| _ITTAD ITTC VSG grupės vadovas |  | 17.8 |
| _ITTAD ITTC TIG vyresnysis inžinierius |  | 17.8 |
| _FD FPAS finansų analitikas |  | 17.8 |
| _FD PS pirkimo vadybininkas |  | 17.8 |
| _FD PS pirkimų vadovas |  | 17.8 |
| _SID Pastočių projektų skyriaus projektų vadovas |  | 17.8 |
| Gintarė Kubilienė | SID PĮS Pastočių rekonstrukcijų grupė | 17.8 |
| _ITTAD ITTC VSG DVS administratorius |  | 17.8 |
| _PTD TCHS PPĮG pastočių inžinierius |  | 17.8 |
| _PTD DSAS aplinkosaugos vyresnysis inžinierius |  | 17.8 |
| _FD FPAS skyriaus vadovas |  | 17.8 |
| Nijolė Ivanicienė | SID Pastočių projektų skyrius | 17.8 |
| Paulius Domarkas | PTD Infrastruktūros priežiūros centras (IPC) | 17.8 |
| _FD PS skyriaus vadovas |  | 17.8 |
| _KS komunikacijos projektų vadovas |  | 17.8 |
| _PTD RAAS RAA inžinierius |  | 17.8 |
| _PTD RAAS RAA vyresnysis inžinierius |  | 17.8 |
| _SVD SPS STRG RAA inžinierius |  | 17.8 |
| _SVD SPS STRG RAA vadovaujantis inžinierius |  | 17.8 |
| _SVD SPS STRG RAA vyresnysis inžinierius |  | 17.8 |
| _VAD departamento vadovas |  | 17.8 |
| _ITTAD ITTC DPG duomenų tinklo administratorius (KR) |  | 17.8 |
| _Projekto savininkas |  | 17.8 |
| _Projekto vadovas |  | 17.8 |
| _PTD DSAS skyriaus vadovas |  | 17.8 |
| _PTD IPC centro vadovas |  | 17.8 |
| _PTD RAAS skyriaus vadovas |  | 17.8 |
| _SID PĮS skyriaus vadovas |  | 17.8 |
| _SID NTPS skyriaus vadovas |  | 17.8 |
| _SD STS vadovaujantis inžinierius |  | 17.8 |
| _SVD SVC Balanso valdymo grupės analitikas |  | 17.8 |
| _PTD TCHS skyriaus vadovas |  | 17.8 |
| _SVD SPS režimų planavimo grupės vadovas |  | 17.8 |
| _SVD SPS STRG grupės vadovas |  | 17.8 |
| _SVD SVC Balanso valdymo grupės vadovas |  | 17.8 |
| _Departamento vadovas |  | 17.8 |
| _Bendrovės vadovas |  | 17.8 |
| _VAD ISS skyriaus vadovas |  | 17.8 |
| _Projekto komanda |  | 17.8 |
| _SID PKS projektų kontrolės vadovas |  | 17.8 |
| _SD PVS vadovas |  | 17.8 |
| _Skyriaus vadovas |  | 17.8 |
| _SVD SPS režimų planavimo grupės inžinierius |  | 17.8 |
| _FD FPAS analitikas-inžinierius |  | 17.8 |
| _FD AS buhalteris |  | 17.8 |
| _SVD SPS režimų planavimo grupės režimų planavimo vadovaujantis inžinierius |  | 17.8 |
| Gintaras Černiauskas | PTD TechS Elektros perdavimo linijų grupė | 17.8 |
| Edvardas Lebedžinskas | PTD TechS RAA įrenginių grupė | 17.8 |
| Ingrida Vygėlienė | SVD SPS Sistemos techninių reikalavimų grupė | 17.8 |
| Jurga Eivaitė | Komunikacijos skyrius | 17.8 |
| Simonas Narščius | SVD SVC Operatyvinio valdymo grupė | 17.8 |
| Rolandas Basakirskas | VAD Fizinės saugos skyrius | 17.8 |
| Neringa Ginaitė | SID Nekilnojamojo turto ir planavimo skyrius | 17.8 |
| Erikas Pleškys | SID Tinklo pertvarkymo projektų skyrius | 17.8 |
| Linas Venckus | PTD Infrastruktūros priežiūros centras (IPC) |  |
| Sigita Ropienė | SID Pastočių projektų skyrius | 17.8 |
| Marius Būga | SID PĮS Tinklo pertvarkymo projektų grupė | 17.8 |
| Marius Kaklauskas | ITTAD ITTC Valdymo sistemų grupė | 17.8 |
| Vytautas Bučelis | ITTAD ITTC Valdymo sistemų grupė | 17.8 |
| Tadas Markevičius | Komunikacijos skyrius | 17.8 |
| Vaiva Barendregt | Komunikacijos skyrius | 17.8 |
| Tadas |  |  |
| Gediminas Arlauskas | PTD IPC Rytų regionas | 17.8 |
| Šarūnas Navickas | PTD TechS RAA įrenginių grupė | 17.8 |
| Gediminas |  |  |
| šarūnas |  |  |
| Vytas Sidaravičius | SVD SVC Tinklo valdymo grupė | 17.8 |
| Oleg Stech | SID Nekilnojamojo turto ir planavimo skyrius | 17.8 |
| Vytas S |  |  |
| Oleg |  |  |
| Rokas Mališauskas | SVD SVC Operatyvinio valdymo grupė | 17.8 |
| Renatas Karalevičius | SID PĮS Pastočių rekonstrukcijų grupė | 17.8 |
| Renatas Karalevčius |  |  |
| Rangovas |  |  |
| Litgrid AB |  |  |
| Ekspertizės rangovas |  |  |
| Infostatyba |  |  |
| ESO |  |  |
| Raimondas Ivoška | PTD TechS Pastočių pirminių įrenginių grupė | 17.8 |
| Julius Jarašūnas | PTD Darbuotojų saugos ir aplinkosaugos skyrius | 17.8 |
| Vaida Laurinavičienė | PTD TechS Elektros perdavimo linijų grupė | 17.8 |
| Vaidotas Riškus | ITTAD ITTC Duomenų perdavimo grupė | 17.8 |
| Marius Sasnauskas | PTD Darbuotojų saugos ir aplinkosaugos skyrius | 17.8 |
| Vygantas Žilius | PTD IPC Vakarų regionas | 17.8 |
| Giedrius Šiurkus | PTD IPC Rytų regionas | 17.8 |
| Lukrecijus Tubys | Komunikacijos skyrius | 17.8 |
| Inga Stravinskienė | SID Pastočių projektų skyrius | 17.8 |
| Mindaugas Šidlauskas | PTD Infrastruktūros priežiūros centras (IPC) | 17.8 |
| Edita Bžeskytė | SID Pastočių projektų skyrius | 17.8 |
| Mantas Varnagiris | PTD TechS Elektros perdavimo linijų grupė | 17.8 |
| Mantas Čepys | VAD Fizinės saugos skyrius | 17.8 |
| Indrė Chščanovičienė | SID Nekilnojamojo turto ir planavimo skyrius | 17.8 |
| Žydrūnas Paviržis | PTD Technikos skyrius | 17.8 |
| Renardas Toliušis | PTD Sisteminių įrenginių priežiūros skyrius | 17.8 |
| Vaida Bytautienė | FD Apskaitos skyrius | 17.8 |
| Darius Malūkas | PTD IPC Rytų regionas | 17.8 |
| Marius Suveizdis | PTD IPC Rytų regionas | 17.8 |
| Andžej Juchnevič | PTD IPC Rytų regionas | 17.8 |
| Adomas Birulis | SID Pastočių projektų skyrius | 17.8 |
| Vytautas Kelevičius | SID Pastočių projektų skyrius | 17.8 |

## Schedule

| ID | WBS | Task | Type | Duration | Start | Finish | Predecessors | Remaining | Baseline 1 start | Baseline 1 finish | Total slack | Free slack | Constraint | Resources | Work | Actual work | Cost | Baseline cost |
| --- | --- | --- | --- | --- | --- | --- | --- | --- | --- | --- | --- | --- | --- | --- | --- | --- | --- | --- |
| 1 | 1 | Pasirašyta rangos sutartis |  | 1d | 2025-10-30 | 2025-10-31 |  |  | 2022-03-30 | 2022-03-30 | 0d |  | start no earlier than 2025-10-30 |  |  |  |  |  |
| 2 | 2 | **Rangos darbų grafikas** |  | 34d | 2025-10-31 | 2025-12-18 |  |  |  |  | 0d |  |  |  | 77.72h |  | 1,272.84 | 663.58 |
| 3 | 2.1 | Pateiktas 1 derinimui darbų grafikas |  | 10d | 2025-10-31 | 2025-11-14 | 1 |  |  |  | 0d |  |  |  |  |  |  |  |
| 4 | 2.2 | Pateiktos pastabos rangos darbų grafikui V1 |  | 14d | 2025-11-14 | 2025-12-04 | 3 |  |  |  | 0d |  | finish no earlier than 2022-03-09 | Darius Žvirblis [5%]; Edvardas Lebedžinskas [5%]; Gintaras Černiauskas [5%]; Gediminas Černiauskas [5%]; Ingrida Vygėlienė [5%]; Kazimieras Ivanauskas [5%]; Kęstutis Rokas [5%]; Linas Venckus [5%]; Mantas Krapavickas [5%]; Mindaugas Štaras [5%]; Pavelas Kuznecovas [5%]; Rimantas Rutkauskas [5%]; Rimas Savukas [5%]; Rytis Šauklys [5%]; Rolandas Basakirskas [5%]; Vidmantas Baliukonis [5%]; Vytas Sidaravičius [5%]; Vytautas Kunigauskas [5%]; Vytenis Povilas Čironis [5%]; Rokas Mališauskas [5%]; Darius Sirgedas [1%]; Darius Vėta [1%]; Gediminas Arlauskas [1%]; Marius Karmonas [1%]; Šarūnas Navickas [1%]; Tomas Kirdonis [1%]; Valdas Rėkus [1%]; Oleg Stech [5%]; Neringa Ginaitė [5%] | 68.38h |  | 1,127.99 | 591.85 |
| 5 | 2.3 | Pateiktas 2 derinimui darbų grafikas V2 |  | 8d | 2025-12-04 | 2025-12-16 | 4 |  |  |  | 229d | 0d | start no earlier than 2022-03-17 | Rytis Šauklys [5%]; Linas Venckus [5%]; Pavelas Kuznecovas [5%]; Rokas Mališauskas [5%]; Tomas Kirdonis [5%]; Valdas Rėkus [5%] | 9.34h |  | 144.85 | 71.73 |
| 6 | 2.4 | Suderintas darbų grafikas |  | 2d | 2025-12-16 | 2025-12-18 | 5 |  |  |  | 229d |  |  |  |  |  |  |  |
| 7 | 3 | **II ETAPAS. RANGOS DARBAI** |  | 10d | 2025-10-31 | 2025-11-14 |  |  |  |  | 248d |  |  |  | 40h |  |  | 5,269.87 |
| 8 | 3.1 | Statybos aikštelės perdavimas rangovui |  | 5d | 2025-10-31 | 2025-11-07 | 1 |  |  |  | 253d | 0d | start no earlier than 2023-03-16 | Litgrid AB | 40h |  |  |  |
| 9 | 3.2 | Reikalingos dokumentacijos perdavimas Rangovui (geodezinė ataskaita, RAA nuostatai, Signalų sąrašai ir kt.) |  | 10d | 2025-10-31 | 2025-11-14 | 1 |  |  |  | 248d | 0d |  |  |  |  |  |  |
| 10 | 4 | **Darbų-atjungimų grafikas** |  | 20d | 2025-12-04 | 2026-01-07 |  |  |  |  | 219d |  |  |  | 200h |  |  |  |
| 11 | 4.1 | Pateiktas darbų-atjungimų grafikas |  | 5d | 2025-12-04 | 2025-12-11 | 4 |  |  |  | 219d | 0d | start no earlier than 2022-10-03 |  |  |  |  |  |
| 12 | 4.2 | Pateiktos pastabos po 1 peržiūros |  | 10d | 2025-12-11 | 2025-12-30 | 11 |  |  |  | 219d | 0d |  | Litgrid AB; ESO | 160h |  |  |  |
| 13 | 4.3 | Pateiktas darbų-atjungimų grafikas 2 peržiūrai |  | 5d | 2025-12-30 | 2026-01-07 | 12 |  |  |  | 219d | 0d |  | Rangovas | 40h |  |  |  |
| 14 | 4.4 | Suderintas darbų-atjungimų grafikas | milestone | 0d | 2026-01-07 | 2026-01-07 | 13 |  |  |  | 219d |  |  | Litgrid AB; ESO |  |  |  |  |
| 15 | 5 | **I etapo statybos montavimo darbai** |  | 258d | 2025-11-07 A | 2026-11-19 |  | 258d |  |  | 0d |  |  |  | 5880h | 565.98h | 6,408 |  |
| 16 | 5.1 | Statybvietės parengiamieji darbai |  | 5d | 2025-11-07 | 2025-11-14 | 8 |  |  |  | 253d |  |  |  |  |  |  |  |
| 17 | 5.2 | Pagrindinės įrangos perdavimas Rangovui |  | 5d | 2025-11-14 | 2025-11-21 | 9 |  |  |  | 248d |  |  |  |  |  |  |  |
| 18 | 5.3 | Įrangos užsakymas, gamyba, pristatymas į objektą (trūkstamų spintų R1, R2, R3 ir S1.1, S1.2) |  | 60d | 2025-12-04 | 2026-03-05 | 4 |  |  |  | 179d |  |  |  |  |  |  |  |
| 19 | 5.4 | Metalo konstrukcijų užsakymas I etapui |  | 30d | 2025-12-04 | 2026-01-21 | 4 |  |  |  | 0d |  |  |  |  |  |  |  |
| 20 | 5.5 | Metalo konstrukcijų sumontavimas |  | 5d | 2026-01-21 | 2026-01-28 | 19 |  |  |  | 184d | 0d | start no earlier than 2025-01-02 |  |  |  |  |  |
| 21 | 5.6 | Pirminių įrenginių sumontavimas |  | 7d | 2026-01-21 | 2026-01-29 | 19 |  |  |  | 0d |  | start no earlier than 2025-01-02 | Rangovas | 56h |  |  |  |
| 22 | 5.7 | RAA, TSPĮ, KSS, NSS, KAS įrangos sumontavimas |  | 20d | 2026-01-28 | 2026-02-26 | 20 |  |  |  | 184d |  | start no earlier than 2025-01-02 | Rangovas | 160h |  |  |  |
| 23 | 5.8 | Kontrolinių ir galios kabelių tiesimas ir pajungimas |  | 20d | 2026-01-28 | 2026-02-26 | 20 |  |  |  | 184d |  | start no earlier than 2025-01-02 | Rangovas | 160h |  |  |  |
| 24 | 5.9 | Pirminių įrenginių (sumontuotų I etape) suderinimas ir išbandymas |  | 20d | 2026-01-30 | 2026-03-02 | 21 |  |  |  | 0d |  |  | Rangovas | 160h |  |  |  |
| 25 | 5.10 | Sklypo tvarkymo, gerbūvio atstatymo, dalis tvoros įrengimo darbai (I etapo daliai) |  | 30d | 2026-03-02 | 2026-04-15 | 24 |  |  |  | 152d |  |  | Rangovas | 240h |  |  |  |
| 26 | 5.11 | Principinės objekto schemos pateikimas (OL permaitinimai ir kt. Pagal suderintą atjungimų grafiką) |  | 5d | 2026-03-02 | 2026-03-09 | 24 |  |  |  | 175d | 0d | start no earlier than 2024-10-04 | Rangovas | 40h |  |  |  |
| 27 | 5.12 | TSM modelio keitimas (dėl I etapo išmontuojamos dalies) |  | 2d | 2026-03-09 | 2026-03-12 | 26 |  |  |  | 175d |  |  | _ITTAD ITTC VSG DVS administratorius | 16h |  | 284.8 | 284.8 |
| 28 | 5.13 | RAA derinimo darbai |  | 20d | 2026-03-02 | 2026-03-31 | 24 |  |  |  | 0d |  | start no earlier than 2024-12-23 | Rangovas | 160h |  |  |  |
| 29 | 5.14 | TSPĮ įrangos derinimo darbai |  | 15d | 2026-03-31 | 2026-04-22 | 28 |  |  |  | 0d |  |  | Rangovas | 120h |  |  |  |
| 30 | 5.15 | Ryšio perjungimo per naujai įrengtą įvadą darbai |  | 1d | 2026-04-21 | 2026-04-22 | 31SF |  |  |  | 147d |  | finish no earlier than 2025-02-10 | Rangovas | 8h |  |  |  |
| 31 | 5.16 | Teleinformacijos testavimai tarp RAA terminalų (valdiklių) ir TSPĮ, KAS duomentų perdavimo testavimo darbai |  | 2d | 2026-04-22 | 2026-04-24 | 29 |  |  |  | 145d | 0d |  | Rangovas; Litgrid AB | 32h |  |  |  |
| 32 | 5.17 | Ryšių; įrangos derinimo darbai; |  | 15d | 2026-03-31 | 2026-04-22 | 29SS |  |  |  | 0d |  | start no earlier than 2025-01-20 | Rangovas | 120h |  |  |  |
| 33 | 5.18 | Užsakymo pateikimas duomenų telekomunikacijų įrangos prijungimui į Litgrid AB TDPT |  | 1d | 2026-04-22 | 2026-04-23 | 32 |  |  |  | 0d |  |  | Rangovas | 8h |  |  |  |
| 34 | 5.19 | Litgrid AB TDPT įrangos parengimas/konfigūravimas naujos telekomunikacijų įrangos (IP; SDH; RRL; Šviesolaidis) prijungimui |  | 3d | 2026-04-23 | 2026-04-28 | 33 |  |  |  | 143d |  |  | Litgrid AB | 24h |  |  |  |
| 35 | 5.20 | RAA OĮB rengimas/tvirtinimas |  | 7d | 2026-04-22 | 2026-05-04 | 29, 32 |  |  |  | 128d | 0d |  | Rangovas; Litgrid AB | 112h |  |  |  |
| 36 | 5.21 | Tipinių perjungimo lapelių ruošimas/tvirtinimas |  | 7d | 2026-05-04 | 2026-05-13 | 35 |  |  |  | 128d | 0d |  | Rangovas | 56h |  |  |  |
| 37 | 5.22 | Įjungimo programos parengimas ir suderinimas |  | 5d | 2026-05-13 | 2026-05-20 | 36 |  |  |  | 128d |  |  | Litgrid AB; Rangovas | 80h |  |  |  |

| ID | WBS | Task | Type | Duration | Start | Finish | Predecessors | Total slack | Free slack | Constraint | Resources | Work |
| --- | --- | --- | --- | --- | --- | --- | --- | --- | --- | --- | --- | --- |
| 38 | 5.23 | **DVS (SCADA/EMS) parengiamieji darbai kompleksiniams bandymams (DVS realaus laiko displėjų parengimas; DVS vystymo sistemos konfigūravimas)** |  | 10d | 2026-04-22 | 2026-05-06 |  | 137d |  |  |  | 80h |
| 39 | 5.23.1 | DVS vystymo sistemos konfigūravimas pagal paskutinį suderintą signalų sąrašą |  | 3d | 2026-04-22 | 2026-04-27 | 32 | 137d | 0d | start no earlier than 2025-02-10 | Litgrid AB | 24h |
| 40 | 5.23.2 | Principinės objekto schemos pateikimas; linijų; transformatorių parametrų pateikimas |  | 3d | 2026-04-27 | 2026-04-30 | 39 | 137d | 0d |  | Rangovas | 24h |
| 41 | 5.23.3 | DVS realaus laiko displėjų parengimas |  | 4d | 2026-04-30 | 2026-05-06 | 39, 40 | 137d |  |  | Litgrid AB | 32h |
| 42 | 5.24 | TSPĮ konfigūracijos pateikimas |  | 1d | 2026-04-23 | 2026-04-24 | 33 | 0d |  | start no earlier than 2025-02-11 | Rangovas | 8h |
| 43 | 5.25 | TSPĮ konfigūracijos derinimas su užsakovu |  | 5d | 2026-04-24 | 2026-05-04 | 42 | 0d |  |  | Litgrid AB | 40h |
| 44 | 5.26 | Įrenginių testavimas bandymai objekte ir/ar tarp skirtingų objektų (pasiruošimas kompleksiniams bandymas) |  | 7d | 2026-05-04 | 2026-05-13 | 43 | 0d |  |  | Rangovas | 56h |
| 45 | 5.27 | Įrenginių kompleksiniai bandymai su PSO SCADA |  | 3d | 2026-05-13 | 2026-05-18 | 44 | 0d |  |  | Rangovas; Litgrid AB | 48h |
| 46 | 5.28 | **DVS (SCADA/EMS) baigiamieji etapo darbai** |  | 8d | 2026-05-18 | 2026-05-27 |  | 122d |  |  |  | 96h |
| 47 | 5.28.1 | Konfigūracijos perkėlimas iš vystymo DVS į darbinę DVS |  | 1d | 2026-05-18 | 2026-05-19 | 45 | 122d | 0d |  | Litgrid AB | 8h |
| 48 | 5.28.2 | Skaičiuojamųjų matavimų sukonfigūravimas DVS |  | 2d | 2026-05-19 | 2026-05-20 | 47 | 122d | 0d |  | Litgrid AB | 16h |
| 49 | 5.28.3 | DVS realaus laiko displėjų parengimo užbaigimas |  | 5d | 2026-05-21 | 2026-05-27 | 48 | 122d |  |  | Litgrid AB | 40h |
| 50 | 5.28.4 | DVS teisių koregavimas (jeigu įtraukiamas naujas objektas) |  | 1d | 2026-05-21 | 2026-05-21 | 48 | 123d | 0d |  | Litgrid AB | 8h |
| 51 | 5.28.5 | TSM modelio keitimas (dėl I etapo) |  | 2d | 2026-05-21 | 2026-05-26 | 50 | 123d | 0d |  | Litgrid AB | 16h |
| 52 | 5.28.6 | TDPT naujos įrangos įvedimas į monitoringo ir valdymo sistemas |  | 1d | 2026-05-26 | 2026-05-27 | 51 | 123d |  |  | Litgrid AB | 8h |
| 53 | 5.29 | **Techninio įvertinimo komisija (I etapo)** |  | 20d | 2026-05-18 | 2026-06-15 |  | 0d |  |  |  | 192h |
| 54 | 5.29.1 | Techninės dokumentacijos pateikimas Užsakovui |  | 2d | 2026-05-18 | 2026-05-20 | 45 | 0d |  |  | Rangovas | 16h |
| 55 | 5.29.2 | Tech. priežiūra derina/pateikia pastabas dokumentacijai |  | 3d | 2026-05-20 | 2026-05-25 | 54 | 0d |  |  | Litgrid AB | 24h |
| 56 | 5.29.3 | Operatyvinio personalo mokymai |  | 1d | 2026-05-25 | 2026-05-26 | 55 | 0d |  |  | Rangovas | 8h |
| 57 | 5.29.4 | Rangovas pateikia raštą dėl TĮK organizavimo (su tech. priežiūros vadovo parašu) |  | 4d | 2026-05-26 | 2026-06-01 | 56 | 0d |  |  | Rangovas | 32h |
| 58 | 5.29.5 | TĮK komisija I-etapo apimtyje | milestone | 0d | 2026-06-01 | 2026-06-01 | 57 | 0d |  |  | Litgrid AB |  |
| 59 | 5.29.6 | TĮK pastabų šalinimas |  | 6d | 2026-06-01 | 2026-06-09 | 58 | 0d |  |  | Rangovas | 48h |
| 60 | 5.29.7 | TP įjungimas; Pasirašytas nurodymas dėl įjungimo (bandomoji ekspoatacija) |  | 4d | 2026-06-09 | 2026-06-15 | 59 | 0d |  |  | Rangovas; Litgrid AB | 64h |
| 61 | 5.29.8 | Bandomosios eksploatacijos pabaiga - įrenginys pilnai veikia (I-etapo apimtyje) | milestone | 0d | 2026-06-15 | 2026-06-15 | 60 | 0d |  |  | Rangovas; Litgrid AB |  |
| 62 | 5.29.9 | Komunikacija (po I etapo užbaigimo, paleista pusė) | milestone | 0d | 2026-06-15 | 2026-06-15 | 61 | 110d |  | finish no earlier than 2023-09-28 | Vaiva Barendregt [5%] |  |

| ID | WBS | Task | Type | Duration | Start | Finish | Predecessors | Remaining | Total slack | Free slack | Constraint | Resources | Work | Actual work | Cost | Baseline cost |
| --- | --- | --- | --- | --- | --- | --- | --- | --- | --- | --- | --- | --- | --- | --- | --- | --- |
| 63 | 5.30 | **II etapo statybos darbai** |  | 100d | 2026-06-15 A | 2026-11-05 |  | 100d | 10d |  |  | Rangovas | 3200h | 565.98h | 6,123.2 | 9,683.2 |
| 64 | 5.30.1 | Planuojamas įrenginių atjungimo laikotarpis (Š2-110, T-2) |  | 100d | 2026-06-15 | 2026-11-05 | 61 |  | 10d |  | start no earlier than 2025-04-16 |  |  |  |  |  |
| 65 | 5.30.2 | **II etapo statybos montavimo darbai** |  | 36d | 2026-06-15 | 2026-08-06 |  |  | 0d |  |  |  | 384h |  |  |  |
| 66 | 5.30.2.1 | Statybvietės parengiamieji darbai |  | 1d | 2026-06-15 | 2026-06-16 | 61 |  | 0d |  | start no earlier than 2025-04-16 | Rangovas | 8h |  |  |  |
| 67 | 5.30.2.2 | Planuojami atjungimai: 110 kV OL Nėris - Paberžė. (OL atramoje atjungti laidus į Š2-110 pusę) | milestone | 0d | 2026-06-16 | 2026-06-16 | 66 |  | 0d |  |  | Litgrid AB; Rangovas |  |  |  |  |
| 68 | 5.30.2.3 | Nemenčinės TP 110 kV AS atjungti TS-100-1 (atjungti OL laidus į TS-100-2 pusę) | milestone | 0d | 2026-06-16 | 2026-06-16 | 67SS |  | 0d |  |  | Litgrid AB; Rangovas |  |  |  |  |
| 69 | 5.30.2.4 | Š2-110 atjungti T-102 ir galios transfotmatorių T-2 iš abiejų pusių (Atjungti OL laidus nuo T2- 110 kV išvadų) | milestone | 0d | 2026-06-16 | 2026-06-16 | 68SS |  | 0d |  |  | ESO; Litgrid AB; Rangovas |  |  |  |  |
| 70 | 5.30.2.5 | Esamų įrenginių II etapo demontavimas |  | 2d | 2026-06-16 | 2026-06-17 | 69 |  | 0d |  |  | Rangovas | 16h |  |  |  |
| 71 | 5.30.2.6 | Pabaigti demontavimo darbai - II etapo apimtyje | milestone | 0d | 2026-06-17 | 2026-06-17 | 70 |  | 107d |  |  |  |  |  |  |  |
| 72 | 5.30.2.7 | Pamatų, kabelinių kanalų II etapui sumontavimas (metalo konstrukcijų sumontavimas) |  | 20d | 2026-06-18 | 2026-07-20 | 70 |  | 0d |  |  | Rangovas | 160h |  |  |  |
| 73 | 5.30.2.8 | Pabaigti pamatų įrengimo darbai - II etapo apimtyje | milestone | 0d | 2026-07-20 | 2026-07-20 | 72 |  | 87d |  |  |  |  |  |  |  |
| 74 | 5.30.2.9 | Pirminių įrenginių sumontavimas (II etapas) |  | 3d | 2026-07-20 | 2026-07-23 | 72 |  | 0d |  |  | Rangovas | 24h |  |  |  |
| 75 | 5.30.2.10 | Sumontuota visa pirminė įranga - II etapo apimtyje | milestone | 0d | 2026-07-23 | 2026-07-23 | 74 |  | 84d |  |  |  |  |  |  |  |
| 76 | 5.30.2.11 | RAA, TSPĮ, KSS, NSS, KAS įrangos pajungimas (II etapui) |  | 3d | 2026-07-23 | 2026-07-28 | 74 |  | 81d |  |  | Rangovas | 24h |  |  |  |
| 77 | 5.30.2.12 | Saulės elektrinės pajungimas, paleidimas, konfigūravimas |  | 3d | 2026-07-23 | 2026-07-28 | 74 |  | 81d |  |  | Rangovas | 24h |  |  |  |
| 78 | 5.30.2.13 | Kontrolinių ir galios kabelių tiesimas ir pajungimas (II etapas) |  | 3d | 2026-07-23 | 2026-07-28 | 74 |  | 81d |  |  | Rangovas | 24h |  |  |  |
| 79 | 5.30.2.14 | Pirminių įrenginių (sumontuotų II etape) suderinimas ir išbandymas |  | 3d | 2026-07-23 | 2026-07-28 | 74 |  | 76d | 0d | start no earlier than 2023-12-14 | Rangovas | 24h |  |  |  |
| 80 | 5.30.2.15 | Sklypo tvarkymo, gerbūvio atstatymo, dalis tvoros įrengimo darbai (II etapo daliai) |  | 10d | 2026-07-23 | 2026-08-06 | 74 |  | 0d |  | start no earlier than 2023-09-21 | Rangovas | 80h |  |  |  |
| 81 | 5.30.3 | **RAA nuostatų pateikimas II statybos etapui** |  | 31d | 2026-06-15 | 2026-07-30 |  |  | 23d |  |  |  | 248h |  |  |  |
| 82 | 5.30.3.1 | OL RAA nuostatų II rekonstrukcijos etapui skaičiavimas |  | 15d | 2026-06-15 | 2026-07-08 | 61 |  | 23d | 0d | start no earlier than 2025-04-16 | Litgrid AB | 120h |  |  |  |
| 83 | 5.30.3.2 | OL RAA nuostatų II rekonstrukcijos etapo užduočių rengimas |  | 15d | 2026-07-08 | 2026-07-29 | 82 |  | 23d | 0d |  | Litgrid AB | 120h |  |  |  |
| 84 | 5.30.3.3 | Užduočių pateikimas |  | 1d | 2026-07-29 | 2026-07-30 | 83 |  | 23d | 0d |  | Litgrid AB | 8h |  |  |  |
| 85 | 5.30.4 | **Gretimų TP RAA nuostatų pateikimas** |  | 11d | 2026-07-30 | 2026-08-14 |  |  | 23d |  |  |  | 88h |  |  |  |
| 86 | 5.30.4.1 | OL RAA nuostatų gretimose TP skaičiavimas |  | 5d | 2026-07-30 | 2026-08-06 | 84 |  | 23d | 0d |  | Litgrid AB | 40h |  |  |  |
| 87 | 5.30.4.2 | OL RAA nuostatų gretimose TP užduočių rengimas |  | 5d | 2026-08-06 | 2026-08-13 | 86 |  | 23d | 0d |  | Litgrid AB | 40h |  |  |  |
| 88 | 5.30.4.3 | Užduočių pateikimas |  | 1d | 2026-08-13 | 2026-08-14 | 87 |  | 23d | 0d |  | Litgrid AB | 8h |  |  |  |
| 89 | 5.30.5 | Principinės objekto schemos pateikimas (OL permaitinimai ir kt. Pagal suderintą atjungimų grafiką) |  | 3d | 2026-06-15 | 2026-06-17 | 61 |  | 104d | 0d | start no earlier than 2025-04-16 | Rangovas | 24h |  |  |  |
| 90 | 5.30.6 | TSM modelio keitimas (dėl II etapo išmontuojamos dalies) |  | 3d | 2026-06-18 | 2026-06-23 | 89 |  | 104d |  |  | _ITTAD ITTC VSG DVS administratorius | 24h |  | 427.2 | 427.2 |
| 91 | 5.30.7 | Sumontuotos RAA spintos - II etapo apimtyje | milestone | 0d | 2026-08-06 | 2026-08-06 | 80 |  | 0d |  | start no earlier than 2025-09-09 | Rangovas |  |  |  |  |
| 92 | 5.30.8 | TSPĮ įrangos derinimo darbai |  | 15d | 2026-08-06 | 2026-08-27 | 91 |  | 0d |  |  | Rangovas | 120h |  |  |  |
| 93 | 5.30.9 | Pastotės RAA terminalų; teleinformacijos surinkimo ir perdavimo įrenginių (TSPĮ); ryšių įrangos; KAS duomentų perdavimo; informacijos saugumo reikalavimų išpildymo tikrinimas su LITGRID AB. |  | 1d | 2026-08-26 | 2026-08-27 | 92FF |  | 59d |  |  | Rangovas | 8h |  |  |  |
| 94 | 5.30.10 | Teleinformacijos testavimai tarp RAA terminalų (valdiklių) ir TSPĮ |  | 1d | 2026-08-27 | 2026-08-28 | 92 |  | 54d | 0d |  | Rangovas; Litgrid AB | 16h |  |  |  |
| 95 | 5.30.11 | Ryšių; įrangos derinimo darbai |  | 10d | 2026-08-06 | 2026-08-20 | 92SS |  | 0d |  |  | Rangovas | 80h |  |  |  |
| 96 | 5.30.12 | Užsakymo pateikimas duomenų telekomunikacijų įrangos prijungimui į Litgrid AB TDPT |  | 5d | 2026-08-20 | 2026-08-27 | 95 |  | 0d |  |  | Litgrid AB | 40h |  |  |  |
| 97 | 5.30.13 | Litgrid AB TDPT įrangos parengimas/konfigūravimas naujos telekomunikacijų įrangos (IP; SDH; RRL; Šviesolaidis) prijungimui (Litgrid AB) |  | 10d | 2026-08-27 | 2026-09-10 | 96 |  | 0d |  |  | _ITTAD ITTC DPG duomenų tinklo administratorius (KR); _ITTAD ITTC TIG vyresnysis inžinierius; Litgrid AB; _ITTAD ITTC DPG duomenų tinklo administratorius (IP) | 320h |  | 4,272 | 6,408 |
| 98 | 5.30.14 | RAA OĮB rengimas/tvirtinimas |  | 5d | 2026-08-27 | 2026-09-03 | 92, 95 |  | 54d |  |  | Rangovas; Litgrid AB | 80h |  |  |  |
| 99 | 5.30.15 | Tipinių perjungimo lapelių ruošimas/tvirtinimas |  | 5d | 2026-07-28 | 2026-08-04 | 79 |  | 76d |  | start no earlier than 2025-08-11 | Rangovas | 40h |  |  |  |

| ID | WBS | Task | Type | Duration | Start | Finish | Predecessors | Total slack | Free slack | Constraint | Resources | Work | Cost | Baseline cost |
| --- | --- | --- | --- | --- | --- | --- | --- | --- | --- | --- | --- | --- | --- | --- |
| 100 | 5.30.16 | **DVS (SCADA/EMS) parengiamieji darbai kompleksiniams bandymams (DVS realaus laiko displėjų parengimas; DVS pagrindinio/rezervinio centro konfigūravimas)** |  | 15d | 2026-08-27 | 2026-09-17 |  | 23d |  |  |  | 120h |  |  |
| 101 | 5.30.16.1 | DVS pagrindinio/rezervinio centro konfigūravimas atsižvelgiant į etapo pasikeitmus 3-5 d.d. |  | 5d | 2026-08-27 | 2026-09-03 | 88FS+9d | 23d | 0d | start no earlier than 2025-08-04 | Litgrid AB | 40h |  |  |
| 102 | 5.30.16.2 | Principinės objekto schemos pateikimas; linijų; transformatorių parametrų pateikimas |  | 5d | 2026-09-03 | 2026-09-10 | 101 | 23d | 0d |  | Rangovas | 40h |  |  |
| 103 | 5.30.16.3 | DVS realaus laiko displėjų parengimas 3-5 d.d. (SVD darbai) |  | 5d | 2026-09-10 | 2026-09-17 | 101, 102 | 44d |  |  | Litgrid AB | 40h |  |  |
| 104 | 5.30.17 | TSPĮ konfigūracijos pateikimas |  | 2d | 2026-08-28 | 2026-09-01 | 94 | 54d | 0d |  | Rangovas | 16h |  |  |
| 105 | 5.30.18 | TSPĮ konfigūracijos derinimas su užsakovu (Litgrid AB) |  | 2d | 2026-09-01 | 2026-09-03 | 104 | 54d |  |  | Litgrid AB | 16h |  |  |
| 106 | 5.30.19 | II etapo įrenginių testavimas bandymai objekte ir/ar tarp skirtingų objektų (pasiruošimas kompleksiniams bandymas) |  | 5d | 2026-09-10 | 2026-09-17 | 97 | 0d |  |  | Rangovas | 40h |  |  |
| 107 | 5.30.20 | Atlikti kompleksiniai bandymai - II etapo apimtyje - sumontuota visa pirminė ir antrinė įranga | milestone | 0d | 2026-09-17 | 2026-09-17 | 106 | 0d |  |  | Rangovas; Litgrid AB |  |  |  |
| 108 | 5.30.21 | **DVS (SCADA/EMS) baigiamojo etapo darbai)** |  | 26d | 2026-09-10 | 2026-10-16 |  | 23d |  |  |  | 408h | 1,424 | 2,848 |
| 109 | 5.30.21.1 | Skaičiuojamųjų matavimų koregavimas DVS |  | 3d | 2026-09-17 | 2026-09-22 | 107 | 29d | 0d | start no earlier than 2025-08-13 | Litgrid AB | 24h |  |  |
| 110 | 5.30.21.2 | DVS realaus laiko displėjų parengimo užbaigimas |  | 7d | 2026-09-22 | 2026-10-01 | 109 | 29d | 0d |  | Litgrid AB | 56h |  |  |
| 111 | 5.30.21.3 | Pateikiama rekonstrukcijos II etapo schema ir parametrai |  | 5d | 2026-10-01 | 2026-10-08 | 110 | 29d |  |  | Rangovas | 40h |  |  |
| 112 | 5.30.21.4 | TSM modelio keitimas (dėl II etapo) |  | 2d | 2026-09-10 | 2026-09-14 | 102 | 23d | 0d |  | Litgrid AB | 16h |  |  |
| 113 | 5.30.21.5 | Visos būtinos dokumentacijos įrenginių įjungimui patvirtinimas/vizavimas; Pateiktas galutinis TPL sąrašas suvedimui į DVS |  | 2d | 2026-09-14 | 2026-09-16 | 112 | 23d | 0d |  | Rangovas | 16h |  |  |
| 114 | 5.30.21.6 | Automatinių tipinių perjungimo lapelių suvedimas į PSO DVS |  | 10d | 2026-09-16 | 2026-09-30 | 113 | 23d | 0d |  | _ITTAD ITTC VSG DVS administratorius | 80h | 1,424 | 2,848 |
| 115 | 5.30.21.7 | Automatinių tipinių perjungimo lapelių testavimas realiomis sąlygomis |  | 10d | 2026-09-30 | 2026-10-14 | 114 | 23d | 0d |  | Rangovas; Litgrid AB | 160h |  |  |
| 116 | 5.30.21.8 | TDPT naujos įrangos įvedimas į monitoringo ir valdymo sistemas |  | 2d | 2026-10-14 | 2026-10-16 | 115 | 23d |  |  | Litgrid AB | 16h |  |  |
| 117 | 5.30.22 | **Techninio įvertinimo komisija (II etapo)** |  | 13d | 2026-09-17 | 2026-10-06 |  | 29d |  |  |  | 312h |  |  |
| 118 | 5.30.22.1 | Techninės dokumentacijos pateikimas Užsakovui |  | 1d | 2026-09-17 | 2026-09-18 | 107 | 29d | 0d | start no earlier than 2025-08-13 | Rangovas | 8h |  |  |
| 119 | 5.30.22.2 | Techninės dokumentacijos pateikimas ir derinimas su Užsakovu |  | 5d | 2026-09-18 | 2026-09-25 | 118 | 29d | 0d |  | Litgrid AB | 192h |  |  |
| 120 | 5.30.22.3 | Operatyvinio personalo mokymai |  | 2d | 2026-09-25 | 2026-09-29 | 119 | 29d | 0d |  | Rangovas | 16h |  |  |
| 121 | 5.30.22.4 | Įjungimo programos rengimas ir derinimas |  | 5d | 2026-09-17 | 2026-09-24 | 107 | 39d |  |  | Rangovas | 40h |  |  |
| 122 | 5.30.22.5 | Techninio įvertinimo komisija II-etapo apimtyje | milestone | 0d | 2026-09-29 | 2026-09-29 | 120 | 29d | 0d |  | Rangovas; Litgrid AB |  |  |  |
| 123 | 5.30.22.6 | Techninio įvertinimo komisijos (II etapo) pastabų šalinimas |  | 3d | 2026-09-29 | 2026-10-02 | 122 | 29d | 0d |  | Rangovas | 24h |  |  |
| 124 | 5.30.22.7 | TP įjungimas; bandomoji ekspoatacija |  | 2d | 2026-10-02 | 2026-10-06 | 123 | 29d | 0d |  | Rangovas; Litgrid AB | 32h |  |  |
| 125 | 5.30.22.8 | TP įjungta | milestone | 0d | 2026-10-06 | 2026-10-06 | 124 | 29d | 0d |  | Rangovas; Litgrid AB |  |  |  |
| 126 | 5.30.23 | RAA nuostatų keitimas gretimose TP |  | 2d | 2026-10-06 | 2026-10-08 | 125 | 29d | 0d |  | Rangovas | 16h |  |  |
| 127 | 5.30.24 | Įjungtas rekonstruotas ar pastatytas objektas | milestone | 0d | 2026-10-08 | 2026-10-08 | 126 | 29d |  |  |  |  |  |  |

Notes:
- 100: (3-5 d.d. priklauso nuo apimties, kiekvieno projekto metu derinama atskirai)
- 108: (14-30 d.d. priklauso nuo apimties, kiekvieno projekto metu derinama atskirai)
- 114: (10-20 d.d.; 50 operacijų į dieną kartu su testavimu imitatoriumi)

| ID | WBS | Task | Type | Duration | Start | Finish | Predecessors | Baseline 1 start | Baseline 1 finish | Total slack | Free slack | Constraint | Resources | Work |
| --- | --- | --- | --- | --- | --- | --- | --- | --- | --- | --- | --- | --- | --- | --- |
| 128 | 5.31 | **III ETAPAS. STATYBOS UŽBAIGIMO AKTAS** |  | 44d | 2026-09-17 | 2026-11-19 |  |  |  | 0d |  |  |  | 608h |
| 129 | 5.31.1 | Išpildomosios topografinės nuotraukos parengimas |  | 4d | 2026-09-17 | 2026-09-23 | 107 |  |  | 27d | 0d |  | Rangovas | 32h |
| 130 | 5.31.2 | VERT pažymos gavimo procedūros |  | 7d | 2026-09-29 | 2026-10-08 | 122 |  |  | 29d | 0d |  |  |  |
| 131 | 5.31.3 | Gauta VERT pažyma - galutinė/baigiamoji | milestone | 0d | 2026-10-08 | 2026-10-08 | 130 |  |  | 29d |  |  |  |  |
| 132 | 5.31.4 | **Statinių kadastrinės bylos parengimas; suderinimas ir registrų centro išankstinė patikra** |  | 13d | 2026-09-23 | 2026-10-12 |  |  |  | 27d |  |  | Rangovas | 208h |
| 133 | 5.31.4.1 | Rangovas rengia statinių kadastrinė bylą |  | 5d | 2026-09-23 | 2026-09-30 | 129 |  |  | 27d | 0d |  | Rangovas | 40h |
| 134 | 5.31.4.2 | Statinių kadastrinės bylos derinimas |  | 8d | 2026-09-30 | 2026-10-12 | 133 |  |  | 27d | 0d | finish no earlier than 2024-06-06 | Litgrid AB | 64h |
| 135 | 5.31.4.3 | Parengtos ir suderintos statinių kadastrinės bylos - išankstinė RC patikra atlikta | milestone | 0d | 2026-10-12 | 2026-10-12 | 134 |  |  | 27d |  | finish no earlier than 2024-06-06 | Rangovas |  |
| 136 | 5.31.5 | **Žemės sklypo kadastrinės bylos parengimas; suderinimas ir registrų centro išankstinė patikra** |  | 15d | 2026-09-17 | 2026-10-08 |  |  |  | 0d |  |  |  | 120h |
| 137 | 5.31.5.1 | Rangovas rengia žemės sklypo kadastrinė bylą |  | 5d | 2026-09-17 | 2026-09-24 | 107 |  |  | 0d |  |  | Rangovas | 40h |
| 138 | 5.31.5.2 | Žemės sklypo kadastrinės bylos derinimas |  | 3d | 2026-09-24 | 2026-09-29 | 137 |  |  | 0d |  |  | Litgrid AB | 24h |
| 139 | 5.31.5.3 | Žemės sklypo kadastrinės bylos išankstinis suderinimas su registrų centru |  | 7d | 2026-09-29 | 2026-10-08 | 138 |  |  | 0d |  | finish no earlier than 2024-06-06 | Rangovas | 56h |
| 140 | 5.31.6 | **Statybos užbaigimo procedūrų organizavimas** |  | 29d | 2026-10-08 | 2026-11-19 |  |  |  | 0d |  |  |  | 248h |
| 141 | 5.31.6.1 | SUA prašymo dokumentų įkėlimas į IS Infostatyba |  | 2d | 2026-10-08 | 2026-10-12 | 139 |  |  | 0d |  | start no earlier than 2024-06-06 | Rangovas | 16h |
| 142 | 5.31.6.2 | Preliminaraus SUA suderinimas su Litgrid AB (atspausdintas iš IS Infostatyba) |  | 2d | 2026-10-12 | 2026-10-14 | 141 |  |  | 0d |  |  | Litgrid AB | 16h |
| 143 | 5.31.6.3 | SUA prašymo pateikimas Infostatyboje |  | 3d | 2026-10-14 | 2026-10-19 | 142 |  |  | 0d |  |  | Rangovas | 24h |
| 144 | 5.31.6.4 | Dokumentų peržiūra |  | 20d | 2026-10-19 | 2026-11-17 | 143 |  |  | 0d |  |  | Infostatyba | 160h |
| 145 | 5.31.6.5 | Galutinė statybos užbaigimo komisija |  | 2d | 2026-11-17 | 2026-11-19 | 144 |  |  | 0d |  |  | Infostatyba; Rangovas | 32h |
| 146 | 5.31.6.6 | Statybos darbų užbaigimo akto arba pažymos pasirašymas | milestone | 0d | 2026-11-19 | 2026-11-19 | 145 | 2024-11-25 | 2024-11-25 | 0d |  |  | Rangovas |  |
